# Software Upgrade Training

Schedule from MS Project, 2013-05-20 to 2013-05-20, 9 hours a day, costs in £.

## Calendars

- Standard: Mon-Fri 08:45-17:45; Sat-Sun off.

## Resources

| Resource | Rate |
| --- | --- |
| Bill | 25 |
| Barbara | 25 |
| Betty | 25 |
| BUDGET STAFF |  |
| BUDGET EQUIPMENT |  |
| BUDGET CATERING |  |
| BUDGET VENUE |  |
| Laptop Hire |  |
| Data Projector |  |
| Engineer | 32 |
| Training Room A |  |
| Tea and Coffees |  |
| Buffet Lunch |  |
| Training Room B |  |
| Training Room C |  |

## Schedule

| ID | WBS | Task | Duration | Start | Finish | Predecessors | Total slack | Resources | Work | Cost |
| --- | --- | --- | --- | --- | --- | --- | --- | --- | --- | --- |
| 1 | 1 | **GROUP A** | 0.92d | 2013-05-20 08:45 | 2013-05-20 17:00 |  | 0d | Engineer [33%]; Training Room A [0.1%] | 10.22h | 1,894.62 |
| 2 | 1.1 | Setup Training Room A | 45min | 2013-05-20 08:45 | 2013-05-20 09:30 |  | 0d | Barbara; Data Projector [0.1%]; Laptop Hire [0.1%] | 0.75h | 1,268.75 |
| 3 | 1.2 | Deliver AM Training Session | 3h | 2013-05-20 09:30 | 2013-05-20 12:30 | 2 | 0d | Barbara; Tea and Coffees [0.1%] | 3h | 100 |
| 4 | 1.3 | Lunch | 45min | 2013-05-20 12:30 | 2013-05-20 13:15 | 3 | 0d | Buffet Lunch [0.1%] |  | 120 |
| 5 | 1.4 | Deliver PM Training Session | 3h | 2013-05-20 13:15 | 2013-05-20 16:15 | 4 | 0d | Barbara; Tea and Coffees [0.1%] | 3h | 100 |
| 6 | 1.5 | Setdown Training Room A | 45min | 2013-05-20 16:15 | 2013-05-20 17:00 | 5 | 0d | Barbara | 0.75h | 18.75 |
| 7 | 2 | **GROUP B** | 0.92d | 2013-05-20 08:45 | 2013-05-20 17:00 |  | 0d | Engineer [33%]; Training Room B [0.1%] | 10.22h | 2,234.62 |
| 8 | 2.1 | Setup Training Room B | 45min | 2013-05-20 08:45 | 2013-05-20 09:30 |  | 0d | Betty; Data Projector [0.1%]; Laptop Hire [0.1%] | 0.75h | 1,568.75 |
| 9 | 2.2 | Deliver AM Training Session | 3h | 2013-05-20 09:30 | 2013-05-20 12:30 | 8 | 0d | Betty; Tea and Coffees [0.1%] | 3h | 105 |
| 10 | 2.3 | Lunch | 45min | 2013-05-20 12:30 | 2013-05-20 13:15 | 9 | 0d | Buffet Lunch [0.1%] |  | 150 |
| 11 | 2.4 | Deliver PM Training Session | 3h | 2013-05-20 13:15 | 2013-05-20 16:15 | 10 | 0d | Betty; Tea and Coffees [0.1%] | 3h | 105 |
| 12 | 2.5 | Setdown Training Room B | 45min | 2013-05-20 16:15 | 2013-05-20 17:00 | 11 | 0d | Betty | 0.75h | 18.75 |
| 13 | 3 | **GROUP C** | 0.92d | 2013-05-20 08:45 | 2013-05-20 17:00 |  | 0d | Engineer [33%]; Training Room C [0.1%] | 10.22h | 2,554.62 |
| 14 | 3.1 | Setup Training Room C | 0.08d | 2013-05-20 08:45 | 2013-05-20 09:30 |  | 0d | Bill; Data Projector [0.1%]; Laptop Hire [0.1%] | 0.75h | 1,868.75 |
| 15 | 3.2 | Deliver AM Training Session | 3h | 2013-05-20 09:30 | 2013-05-20 12:30 | 14 | 0d | Bill; Tea and Coffees [0.1%] | 3h | 110 |
| 16 | 3.3 | Lunch | 45min | 2013-05-20 12:30 | 2013-05-20 13:15 | 15 | 0d | Buffet Lunch [0.1%] |  | 160 |
| 17 | 3.4 | Deliver PM Training Session | 3h | 2013-05-20 13:15 | 2013-05-20 16:15 | 16 | 0d | Bill; Tea and Coffees [0.1%] | 3h | 110 |
| 18 | 3.5 | Setdown Training Room C | 45min | 2013-05-20 16:15 | 2013-05-20 17:00 | 17 | 0d | Bill | 0.75h | 18.75 |
